# Project_01_draftplan

Schedule from MS Project, 2023-11-01 to 2024-11-05.

## Calendars

- Standard: Mon-Fri 08:00-12:00, 13:00-17:00; Sat-Sun off.

## Schedule

| ID | WBS | Task | Duration | Start | Finish | Predecessors | Total slack | Free slack |
| --- | --- | --- | --- | --- | --- | --- | --- | --- |
| 1 | 1.1 | **Phase: Initiation and contract/plan definition** | 75d | 2023-11-01 | 2024-02-13 |  | 0d |  |
| 2 | 1.1.1 | Develop Scope and Plan | 4w | 2023-11-01 | 2023-11-28 |  | 0d |  |
| 3 | 1.1.3 | Define contract | 4w | 2023-11-29 | 2023-12-26 | 2 | 0d |  |
| 4 | 1.1.4 | System design - define IT and engineering requirements | 4w | 2023-12-27 | 2024-01-23 | 3 | 0d |  |
| 5 | 1.1.5 | Define revised cost estimates, and risk management plan | 2w | 2024-01-24 | 2024-02-06 | 4 | 0d |  |
| 6 | 1.1.6 | Approval of new revised budget and staffing | 1w | 2024-02-07 | 2024-02-13 | 5 | 0d |  |
| 7 | 1.2 | **Phase: Drones and operations adaptation activities** | 90d | 2024-02-14 | 2024-06-18 | 6 | 100d |  |
| 8 | 1.2.1 | Drone flight operations processes adaptation | 2w | 2024-02-14 | 2024-02-27 |  | 100d | 0d |
| 9 | 1.2.2 | Engineering requirements for drone changes | 2w | 2024-02-28 | 2024-03-12 | 8 | 100d | 0d |
| 10 | 1.2.3 | Approval of engineering changes and associated costs | 1w | 2024-03-13 | 2024-03-19 | 9 | 100d | 0d |
| 11 | 1.2.4 | Engineering sub-project | 12w | 2024-03-20 | 2024-06-11 | 10 | 100d | 0d |
| 12 | 1.2.5 | Approval of tests of modified drones | 1w | 2024-06-12 | 2024-06-18 | 11 | 100d |  |
| 13 | 1.3 | **Phase: IT integration development** | 115d | 2024-02-14 | 2024-07-23 | 6 | 0d |  |
| 14 | 1.3.1 | Prototype and pilot test with stakeholders proposed integration on mock-up, including data | 2w | 2024-02-14 | 2024-02-27 |  | 0d |  |
| 15 | 1.3.2 | Develop mobile app and all other software and dataflows integration | 11w | 2024-02-28 | 2024-05-14 | 14 | 0d |  |
| 16 | 1.3.3 | Approval of software application for integration | 1w | 2024-05-15 | 2024-05-21 | 15 | 0d |  |
| 17 | 1.3.4 | Integrate software and data with Wilmont and test | 8w | 2024-05-22 | 2024-07-16 | 16 | 0d |  |
| 18 | 1.3.5 | Final IT systems integration approval | 1w | 2024-07-17 | 2024-07-23 | 17 | 0d |  |
| 19 | 1.4 | **Phase: integration software and drones** | 30d | 2024-07-24 | 2024-09-03 | 18 | 0d |  |
| 20 | 1.4.1 | Test integration of all the software components with hardware | 3w | 2024-07-24 | 2024-08-13 |  | 55d | 0d |
| 21 | 1.4.2 | Approval of hardware and software integration results | 1w | 2024-08-14 | 2024-08-20 | 20 | 55d |  |
| 22 | 1.4.3 | Develop operational manuals and training material, pilot training | 6w | 2024-07-24 | 2024-09-03 | 18 | 0d |  |
| 23 | 1.5 | **Phase: Start operations** | 45d | 2024-09-04 | 2024-11-05 | 22 | 0d |  |
| 24 | 1.5.1 | Approval final go/nogo | 1w | 2024-09-04 | 2024-09-10 |  | 0d |  |
| 25 | 1.5.2 | Deliver training to stores and operational staff | 3w | 2024-09-11 | 2024-10-01 | 24 | 0d |  |
| 26 | 1.5.3 | Communication/advertisement plan execution | 3w | 2024-10-02 | 2024-10-22 | 25 | 0d |  |
| 27 | 1.5.4 | Initiate deliveries by drone | 2w | 2024-10-23 | 2024-11-05 | 26 | 0d |  |
